# testing2

Schedule from MS Project, 2022-08-30 to 2025-01-01, status date 2022-08-30, costs in RM.

## Calendars

- Standard: Mon-Fri 08:00-12:00, 13:00-17:00; Sat-Sun off.

## Resources

| Resource |
| --- |
| Original Duration |
| 0 |
| 49 |
| 19 |
| 7 |
| 21 |
| 38 |
| 11 |
| 5 |
| 42 |
| 30 |
| 32 |
| 3 |
| 9 |
| 6 |
| 370 |
| 1 |
| 13 |
| 15 |
| 244 |

## Schedule

| ID | WBS | Task | Type | Duration | Start | Finish | Predecessors | Total slack | Free slack | Cost |
| --- | --- | --- | --- | --- | --- | --- | --- | --- | --- | --- |
| 1 | 1 | **Scheduler Sample** |  | 612d | 2022-08-30 | 2025-01-01 |  | 0d |  | 640,094.4 |
| 2 | 1.1 | **Design and Engineering** |  | 96d | 2022-08-30 | 2023-01-10 |  | 0d |  | 45,360 |
| 3 | 1.1.1 | Start Office Building Addition Project | milestone | 0d | 2022-08-30 | 2022-08-30 |  | 0d |  |  |
| 4 | 1.1.2 | Design Building Addition |  | 49d | 2022-08-30 | 2022-11-04 | 3 | 0d |  | 23,184 |
| 5 | 1.1.3 | Review and Approve Designs |  | 19d | 2022-11-07 | 2022-12-01 | 4 | 0d |  | 9,072 |
| 6 | 1.1.4 | Assemble Technical Data for Heat Pump |  | 7d | 2022-12-02 | 2022-12-12 | 5 | 0d |  | 3,024 |
| 7 | 1.1.5 | Review Technical Data on Heat Pumps |  | 21d | 2022-12-13 | 2023-01-10 | 6 | 0d |  | 10,080 |
| 8 | 1.2 | **Foundation** |  | 128d | 2022-12-01 | 2023-05-30 |  | 106d |  | 118,659.2 |
| 9 | 1.2.1 | Begin Building Construction | milestone | 0d | 2022-12-01 | 2022-12-01 | 5 | 106d | 0d |  |
| 10 | 1.2.2 | Site Preparation |  | 38d | 2022-12-02 | 2023-01-24 | 9SS | 106d | 0d | 21,168 |
| 11 | 1.2.3 | Excavation |  | 21d | 2023-01-25 | 2023-02-22 | 10 | 106d | 0d | 11,760 |
| 12 | 1.2.4 | Install Underground Water Lines |  | 11d | 2023-02-23 | 2023-03-09 | 11 | 106d | 0d | 4,620 |
| 13 | 1.2.5 | Install Underground Electric Conduit |  | 11d | 2023-02-23 | 2023-03-09 | 11 | 106d | 0d | 7,980 |
| 14 | 1.2.6 | Form/Pour Concrete Footings |  | 21d | 2023-03-10 | 2023-04-07 | 12, 13 | 106d | 0d | 27,680 |
| 15 | 1.2.7 | Concrete Foundation Walls |  | 21d | 2023-04-10 | 2023-05-08 | 14 | 106d | 0d | 23,480 |
| 16 | 1.2.8 | Form and Pour Slab |  | 11d | 2023-05-09 | 2023-05-23 | 15 | 106d | 0d | 17,368 |
| 17 | 1.2.9 | Backfill and Compact Walls |  | 5d | 2023-05-24 | 2023-05-30 | 16 | 106d | 0d | 4,603.2 |
| 18 | 1.2.10 | Foundation Phase Complete | milestone | 0d | 2023-05-30 | 2023-05-30 | 17 | 416d |  |  |
| 19 | 1.3 | **Structure** |  | 136d | 2023-05-31 | 2023-12-06 |  | 106d |  | 125,496 |
| 20 | 1.3.1 | Erect Structural Frame |  | 42d | 2023-05-31 | 2023-07-27 | 17 | 106d | 0d | 10,840 |
| 21 | 1.3.2 | Begin Structural Phase | milestone | 0d | 2023-07-27 | 2023-07-27 | 20 | 374d |  |  |
| 22 | 1.3.3 | Floor Decking |  | 30d | 2023-07-28 | 2023-09-07 | 20 | 106d | 0d | 14,056 |
| 23 | 1.3.4 | Concrete First Floor |  | 32d | 2023-09-08 | 2023-10-23 | 22 | 106d | 0d | 26,652 |
| 24 | 1.3.5 | Erect Stairwell and Elevator Walls |  | 21d | 2023-10-24 | 2023-11-21 | 23 | 117d | 0d | 5,880 |
| 25 | 1.3.6 | Concrete Basement Slab |  | 21d | 2023-10-24 | 2023-11-21 | 23 | 117d | 11d | 41,416 |
| 26 | 1.3.7 | Concrete Second Floor |  | 32d | 2023-10-24 | 2023-12-06 | 23 | 106d | 0d | 26,652 |
| 27 | 1.3.8 | Structure Complete | milestone | 0d | 2023-12-06 | 2023-12-06 | 24, 25, 26 | 106d | 0d |  |

| ID | WBS | Task | Type | Duration | Start | Finish | Predecessors | Total slack | Free slack | Cost |
| --- | --- | --- | --- | --- | --- | --- | --- | --- | --- | --- |
| 28 | 1.4 | **Machanical/Electrical Systems** |  | 511d | 2023-01-11 | 2024-12-25 |  | 0d |  | 162,836 |
| 29 | 1.4.1 | Rough-In Phase Begins | milestone | 0d | 2023-11-01 | 2023-11-01 | 47 | 205d | 14d |  |
| 30 | 1.4.2 | Rough In Complete | milestone | 0d | 2024-08-19 | 2024-08-19 | 43, 32 | 0d |  |  |
| 31 | 1.4.3 | **Elevator** |  | 199d | 2023-11-22 | 2024-08-26 |  | 81d |  | 5,292 |
| 32 | 1.4.3.1 | Install Elevator Rails and Equipment |  | 3d | 2023-11-22 | 2023-11-24 | 29, 24 | 191d |  | 1,764 |
| 33 | 1.4.3.2 | Install Elevator Cab and Finishes |  | 5d | 2024-08-20 | 2024-08-26 | 30, 53 | 81d |  | 3,528 |
| 34 | 1.4.4 | **HVAC** |  | 511d | 2023-01-11 | 2024-12-25 |  | 0d |  | 110,880 |
| 35 | 1.4.4.1 | Prepare and Solicit Bids for Heat Pump |  | 13d | 2023-01-11 | 2023-01-27 | 7 | 0d |  | 2,772 |
| 36 | 1.4.4.2 | Review Bids for Heat Pump |  | 9d | 2023-01-30 | 2023-02-09 | 35 | 0d |  | 1,848 |
| 37 | 1.4.4.3 | Award Contract for Heat Pump |  | 6d | 2023-02-10 | 2023-02-17 | 36 | 0d |  |  |
| 38 | 1.4.4.4 | Fabricate and Deliver Heat Pump and Controls |  | 370d | 2023-02-20 | 2024-07-19 | 37 | 0d |  | 81,312 |
| 39 | 1.4.4.5 | Install HVAC Ducts |  | 21d | 2023-11-02 | 2023-11-30 | 47 | 165d | 0d | 7,392 |
| 40 | 1.4.4.6 | Insulate Ducts |  | 5d | 2024-01-26 | 2024-02-01 | 39, 53 | 239d |  | 1,478.4 |
| 41 | 1.4.4.7 | Set Heat Pump |  | 11d | 2024-07-22 | 2024-08-05 | 39, 53, 38 | 0d |  | 5,040 |
| 42 | 1.4.4.8 | Relocate HVAC Chiller |  | 7d | 2024-08-06 | 2024-08-14 | 41 | 0d |  | 8,013.6 |
| 43 | 1.4.4.9 | Startup and Test HVAC |  | 3d | 2024-08-15 | 2024-08-19 | 42, 50, 29 | 0d |  | 2,016 |
| 44 | 1.4.4.10 | Install AC Grills and Registers |  | 5d | 2024-10-15 | 2024-10-21 | 85SS+8d | 19d |  |  |
| 45 | 1.4.4.11 | Test and Balance HVAC Equipment |  | 3d | 2024-12-23 | 2024-12-25 | 69 | 0d |  | 1,008 |
| 46 | 1.4.5 | **Plumbing and Electrical** |  | 231d | 2023-09-19 | 2024-08-06 |  | 6d |  | 46,664 |
| 47 | 1.4.5.1 | Set Mechanical and Electrical Equipment |  | 32d | 2023-09-19 | 2023-11-01 | 23SS+7d | 165d | 0d | 15,120 |
| 48 | 1.4.5.2 | Rough-In Plumbing/Piping |  | 3d | 2023-11-08 | 2023-11-10 | 39SS+4d | 165d | 59d | 7,604 |
| 49 | 1.4.5.3 | Install Wiring and Cable |  | 32d | 2024-02-02 | 2024-03-18 | 53SS+5d, 48 | 106d | 100d | 23,940 |
| 50 | 1.4.5.4 | Connect Equipment |  | 1d | 2024-08-06 | 2024-08-06 | 49, 41 | 6d |  |  |
| 51 | 1.5 | **Exterior Finishes** |  | 300d | 2022-12-01 | 2024-01-25 |  | 244d |  | 37,440.8 |
| 52 | 1.5.1 | Close-In Phase Begins | milestone | 0d | 2023-12-27 | 2023-12-27 | 61 | 265d |  |  |
| 53 | 1.5.2 | Building Enclosed | milestone | 0d | 2024-01-25 | 2024-01-25 | 66, 63 | 106d | 0d |  |

| ID | WBS | Task | Type | Duration | Start | Finish | Predecessors | Total slack | Free slack | Cost |
| --- | --- | --- | --- | --- | --- | --- | --- | --- | --- | --- |
| 54 | 1.5.3 | **Brick** |  | 279d | 2022-12-01 | 2023-12-27 |  | 106d |  | 27,384 |
| 55 | 1.5.3.1 | Assemble Brick Samples | milestone | 0d | 2022-12-01 | 2022-12-01 | 5 | 317d | 0d |  |
| 56 | 1.5.3.2 | Review and Approve Brick Samples |  | 21d | 2022-12-02 | 2022-12-30 | 55 | 317d | 0d | 10,080 |
| 57 | 1.5.3.3 | Prepare and Solicit Bids for Brick Exterior |  | 13d | 2023-01-02 | 2023-01-18 | 56 | 317d | 0d | 2,772 |
| 58 | 1.5.3.4 | Review Bids for Brick |  | 13d | 2023-01-19 | 2023-02-06 | 57 | 317d | 0d | 2,772 |
| 59 | 1.5.3.5 | Award Contract for Brick |  | 5d | 2023-02-07 | 2023-02-13 | 58 | 317d | 0d | 924 |
| 60 | 1.5.3.6 | Deliver Brick |  | 1d | 2023-02-14 | 2023-02-14 | 59 | 317d | 211d |  |
| 61 | 1.5.3.7 | Brick Exterior Walls |  | 15d | 2023-12-07 | 2023-12-27 | 60, 27 | 106d | 0d | 10,836 |
| 62 | 1.5.4 | **Roof** |  | 21d | 2023-12-28 | 2024-01-25 |  | 106d |  | 6,680 |
| 63 | 1.5.4.1 | Insulation and Built-up Roofing |  | 21d | 2023-12-28 | 2024-01-25 | 66FF, 61 | 106d | 0d | 6,680 |
| 64 | 1.5.5 | **Door and Windows** |  | 8d | 2023-12-14 | 2023-12-25 |  | 129d |  | 3,376.8 |
| 65 | 1.5.5.1 | Install Door and Window Frames |  | 3d | 2023-12-14 | 2023-12-18 | 61SS+5d | 129d | 0d | 1,125.6 |
| 66 | 1.5.5.2 | Install Exterior Doors and Windows |  | 5d | 2023-12-19 | 2023-12-25 | 65 | 129d | 23d | 2,251.2 |
| 67 | 1.6 | **Interior Finishes** |  | 544d | 2022-12-01 | 2025-01-01 |  | 0d |  | 150,302.4 |
| 68 | 1.6.1 | Drywall in Offices |  | 32d | 2024-08-20 | 2024-10-02 | 53, 30 | 0d |  | 16,884 |
| 69 | 1.6.2 | Touch-up and Clean-up |  | 3d | 2024-12-18 | 2024-12-20 | 75, 86, 88, 33 | 0d |  | 4,211.2 |
| 70 | 1.6.3 | Finishes Complete | milestone | 0d | 2024-12-25 | 2024-12-25 | 45 | 0d |  |  |
| 71 | 1.6.4 | Punch List |  | 5d | 2024-12-26 | 2025-01-01 | 70 | 0d |  | 4,211.2 |
| 72 | 1.6.5 | Building Addition Complete | milestone | 0d | 2025-01-01 | 2025-01-01 | 71 | 0d |  |  |
| 73 | 1.6.6 | **Plumbing and Lighting Fixtures** |  | 40d | 2024-10-15 | 2024-12-09 |  | 6d |  | 11,676 |
| 74 | 1.6.6.1 | Install Lighting Fixtures |  | 7d | 2024-10-15 | 2024-10-23 | 85SS+8d | 17d |  | 9,828 |
| 75 | 1.6.6.2 | Install Plumbing Fixtures |  | 5d | 2024-12-03 | 2024-12-09 | 83 | 6d |  | 1,848 |
| 76 | 1.6.7 | **Floor and Carpeting** |  | 522d | 2022-12-01 | 2024-12-02 |  | 0d |  | 75,768 |
| 77 | 1.6.7.1 | Assemble and Submit Flooring Samples | milestone | 0d | 2022-12-01 | 2022-12-01 | 5 | 207d | 0d |  |
| 78 | 1.6.7.2 | Review and Approve Flooring |  | 21d | 2022-12-02 | 2022-12-30 | 77 | 207d | 0d | 10,080 |
| 79 | 1.6.7.3 | Prepare and Solicit Bids for Flooring |  | 21d | 2023-01-02 | 2023-01-30 | 78 | 207d | 0d | 4,620 |
| 80 | 1.6.7.4 | Review Bids for Flooring |  | 13d | 2023-01-31 | 2023-02-16 | 79 | 207d | 0d | 2,772 |
| 81 | 1.6.7.5 | Award Contract for Flooring |  | 5d | 2023-02-17 | 2023-02-23 | 80 | 207d | 0d | 924 |
| 82 | 1.6.7.6 | Fabricate and Deliver Flooring |  | 244d | 2023-02-24 | 2024-01-31 | 81 | 207d |  | 53,592 |
| 83 | 1.6.7.7 | Install Floor and Carpeting |  | 11d | 2024-11-18 | 2024-12-02 | 82, 74, 85, 44 | 0d |  | 3,780 |

| ID | WBS | Task | Duration | Start | Finish | Predecessors | Total slack | Cost |
| --- | --- | --- | --- | --- | --- | --- | --- | --- |
| 84 | 1.6.8 | **Carpentry** | 54d | 2024-10-03 | 2024-12-17 |  | 0d | 31,672 |
| 85 | 1.6.8.1 | Install Ceiling Grid | 32d | 2024-10-03 | 2024-11-15 | 68 | 0d | 26,044 |
| 86 | 1.6.8.2 | Finish Carpentry and Millwork | 11d | 2024-12-03 | 2024-12-17 | 83 | 0d | 5,628 |
| 87 | 1.6.9 | **Paint** | 11d | 2024-08-29 | 2024-09-12 |  | 68d | 5,880 |
| 88 | 1.6.9.1 | Paint Building Interior | 11d | 2024-08-29 | 2024-09-12 | 68SS+7d | 68d | 5,880 |
